# Home Construction

Schedule from Primavera P6, 2014-10-14 to 2014-11-29, data date 2014-10-23, costs in USD, A marks actual dates.

## Calendars

- Calendar 1: Mon off; Tue-Sat 09:00-14:00, 15:00-19:00; Sun off.

## Resources

| Resource | Group | Unit | Rate |
| --- | --- | --- | --- |
| Daniel Muller | labor |  | 55 |
| Land Surveyor | labor |  | 65 |
| Operating Engineer | labor |  | 60 |
| Engineer Labor | labor |  | 18 |
| Steel Crew | equipment |  | 49 |
| Carpentry Crew | equipment |  | 52 |
| Concrete | material | cu yd | 10 |
| Masonry Crew | equipment |  | 40 |
| Plumbing Crew | equipment |  | 58 |
| Skilled Laborer | labor |  | 19.5 |
| Richard Collins | labor |  | 40 |
| Barb Wire, Senior Electrical Engineer | labor |  | 41 |
| Electrical Crew | equipment |  | 52 |
| Glass Crew | equipment |  | 70 |
| Landscape Crew | equipment |  | 72 |

## Schedule

| ID | WBS | Activity | Type | Duration | Start | Finish | Predecessors | Complete | Remaining | Planned start | Planned finish | Total float | Free float | Resources | Cost | Actual cost |
| --- | --- | --- | --- | --- | --- | --- | --- | --- | --- | --- | --- | --- | --- | --- | --- | --- |
| A1000 |  | Project Start | milestone | 0d | 2014-10-14 A | 2014-10-14 A |  | 100% |  |  |  |  |  |  |  |  |
| A1010 |  | Project Management | level of effort | 32d | 2014-10-14 A | 2014-11-28 | A1000 SS | 6% | 30d | 2014-10-14 | 2014-11-21 | 1d | 0d | Daniel Muller [256 h] | 14,080 | 880 |
| A1020 |  | Project Complete | milestone | 0d | 2014-11-28 | 2014-11-28 | A1010 FF, A1150, A1170 FF, A1210 FF, A1240 FF |  |  |  |  | 1d |  |  |  |  |
|  | 1 | **Grading** |  |  | 2014-10-14 | 2014-10-18 |  |  |  |  |  |  |  |  |  |  |
| A1030 |  | Survey and mark out Site |  | 2d | 2014-10-14 A | 2014-10-15 A | A1000 SS | 100% |  |  |  |  |  | Land Surveyor [16 h] | 1,040 |  |
| A1040 |  | Grade Site |  | 5d | 2014-10-15 A | 2014-10-18 A | A1030 | 100% |  | 2014-10-15 | 2014-10-22 |  |  | Operating Engineer [40 h] | 2,400 | 2,400 |
|  | 2 | **Foundation** |  |  | 2014-10-18 | 2014-11-01 |  |  |  |  |  |  |  |  |  |  |
| A1050 |  | Laying of Foundation |  | 2d | 2014-10-18 A | 2014-10-22 A | A1040 | 100% |  |  |  |  |  | Engineer Labor [16 h]; Steel Crew [16 h]; Carpentry Crew [16 h]; Concrete [16 cu yd]; Masonry Crew [16 h] | 2,704 |  |
| A1060 |  | Slab Plumbing |  | 1d | 2014-10-23 | 2014-10-23 | A1050 |  |  |  |  | 0d |  | Plumbing Crew [8 h] | 464 |  |
| A1070 |  | Pour and float slab concrete |  | 8d | 2014-10-23 | 2014-11-01 | A1060 |  |  |  |  | 0d |  | Concrete [64 cu yd] | 640 |  |
|  | 3 | **Structure** |  |  | 2014-10-23 | 2014-11-29 |  |  |  |  |  |  |  |  |  |  |
|  | 1 | **Framing** |  |  | 2014-11-12 | 2014-11-25 |  |  |  |  |  |  |  |  |  |  |
| A1080 |  | Exterior Walls |  | 6d | 2014-11-12 | 2014-11-19 | A1070 FS+7d |  |  |  |  | 0d |  | Masonry Crew [48 h] | 1,920 |  |
| A1090 |  | Interior Walls |  | 4d | 2014-11-19 | 2014-11-25 | A1080 |  |  |  |  | 5d |  | Masonry Crew [32 h] | 1,280 |  |
| A1100 |  | Exterior Cladding |  | 2d | 2014-11-19 | 2014-11-21 | A1080 |  |  |  |  | 1d | 0d | Masonry Crew [16 h] | 640 |  |
|  | 2 | **Roof** |  |  | 2014-11-19 | 2014-11-25 |  |  |  |  |  |  |  |  |  |  |
| A1110 |  | Truss Placing |  | 2d | 2014-11-19 | 2014-11-21 | A1080 |  |  |  |  | 2d | 0d | Steel Crew [16 h] | 784 |  |
| A1120 |  | Roof Sheeting |  | 1d | 2014-11-21 | 2014-11-22 | A1110 |  |  |  |  | 2d | 0d | Skilled Laborer [8 h] | 156 |  |
| A1130 |  | Place Paper and Shingles |  | 2d | 2014-11-22 | 2014-11-25 | A1120 |  |  |  |  | 2d | 0d | Skilled Laborer [16 h] | 312 |  |
|  | 3 | **Interior** |  |  | 2014-10-23 | 2014-11-29 |  |  |  |  |  |  |  |  |  |  |
|  | 1 | **Mechanical** |  |  | 2014-11-26 | 2014-11-27 |  |  |  |  |  |  |  |  |  |  |
| A1140 |  | HVAC Ducting |  | 2d | 2014-11-26 | 2014-11-27 | A1130 |  |  |  |  | 2d | 0d | Richard Collins [16 h] | 640 |  |
| A1150 |  | Install HVAC Unit |  | 1d | 2014-11-26 | 2014-11-26 | A1140 SS |  |  |  |  | 3d | 2d | Richard Collins [8 h] | 320 |  |
|  | 2 | **Electrical** |  |  | 2014-11-19 | 2014-11-26 |  |  |  |  |  |  |  |  |  |  |
| A1160 |  | Breaker Box and Rough Wiring |  | 3d | 2014-11-19 | 2014-11-22 | A1080 |  |  |  |  | 3d | 0d | Barb Wire, Senior Electrical Engineer [24 h]; Electrical Crew [24 h] | 2,232 |  |
| A1170 |  | Finish Wiring |  | 3d | 2014-11-22 | 2014-11-26 | A1160 |  |  |  |  | 3d | 2d | Electrical Crew [24 h] | 1,248 |  |

| ID | WBS | Activity | Duration | Start | Finish | Predecessors | Total float | Free float | Resources | Cost |
| --- | --- | --- | --- | --- | --- | --- | --- | --- | --- | --- |
|  | 3 | **Plumbing** |  | 2014-11-19 | 2014-11-25 |  |  |  |  |  |
| A1180 |  | Install Rough Plumbing Lines | 4d | 2014-11-19 | 2014-11-25 | A1080 | 0d |  | Plumbing Crew [32 h] | 1,856 |
|  | 4 | **Decor** |  | 2014-10-23 | 2014-11-29 |  |  |  |  |  |
| A1210 |  | Kitchen Cabinets | 5d | 2014-10-23 | 2014-10-29 |  | 26d | 25d | Carpentry Crew [40 h] | 2,080 |
| A1190 |  | Placing Doors | 2d | 2014-11-25 | 2014-11-26 | A1180 | 0d |  | Carpentry Crew [16 h] | 832 |
| A1200 |  | Doors Casing and Baseboards | 3d | 2014-11-26 | 2014-11-29 | A1190 | 0d |  | Carpentry Crew [24 h] | 1,248 |
|  | 4 | **Exterior** |  | 2014-11-21 | 2014-11-27 |  |  |  |  |  |
| A1220 |  | Place Windows | 2d | 2014-11-21 | 2014-11-25 | A1100 | 1d | 0d | Glass Crew [16 h] | 1,120 |
| A1230 |  | Window Sidings | 3d | 2014-11-25 | 2014-11-27 | A1220 | 1d | 0d | Carpentry Crew [24 h] | 1,248 |
|  | 5 | **Landscaping** |  | 2014-11-27 | 2014-11-28 |  |  |  |  |  |
| A1240 |  | Tree Plantings | 1d | 2014-11-27 | 2014-11-28 | A1230 | 1d | 0d | Landscape Crew [8 h] | 576 |

## Risks

| Risk | Status | Probability |
| --- | --- | --- |
| Non availability of masonry crew | RS_Open | 90 |
| Non availability of roof sheeting manpower | RS_Open | 90 |

## Issues

| Issue | Status | Raised |
| --- | --- | --- |
| Start Date Variance (days) is 0 on WBS: CD00720.2 | IS_Open | 2014-10-17 |
| Start Date Variance (days) is 0 on WBS: CD00720.2 | IS_Open | 2014-10-17 |
| Start Date Variance (days) is 0 on WBS: CD00720 | IS_Open | 2014-10-17 |
| Start Date Variance (days) is 0 on WBS: CD00720.1 | IS_Open | 2014-10-17 |
| Start Date Variance (days) is 0 on WBS: CD00720.21 | IS_Open | 2014-10-17 |
| Start Date Variance (days) is 0 on WBS: CD00720.3 | IS_Open | 2014-10-17 |
| Start Date Variance (days) is 0 on WBS: CD00720.3.1 | IS_Open | 2014-10-17 |
| Start Date Variance (days) is 0 on WBS: CD00720.3.2 | IS_Open | 2014-10-17 |
| Start Date Variance (days) is 0 on WBS: CD00720.3.3 | IS_Open | 2014-10-17 |
| Start Date Variance (days) is 0 on WBS: CD00720.3.3.1 | IS_Open | 2014-10-17 |
| Start Date Variance (days) is 0 on WBS: CD00720.3.3.2 | IS_Open | 2014-10-17 |
| Start Date Variance (days) is 0 on WBS: CD00720.3.3.3 | IS_Open | 2014-10-17 |
| Start Date Variance (days) is 0 on WBS: CD00720.3.3.4 | IS_Open | 2014-10-17 |
| Start Date Variance (days) is 0 on WBS: CD00720.3.4 | IS_Open | 2014-10-17 |
| Start Date Variance (days) is 0 on WBS: CD00720.3.5 | IS_Open | 2014-10-17 |
